# 机考数据中心开发计划

Schedule from MS Project, 2017-11-01 to 2017-12-15.

## Calendars

- 标准: Mon-Fri 08:00-12:00, 13:00-17:00; Sat-Sun off.

## Resources

| Resource |
| --- |
| 田军 |
| 高兴 |

## Schedule

| ID | WBS | Task | Duration | Start | Finish | Predecessors | Total slack | Free slack | Constraint | Resources | Work |
| --- | --- | --- | --- | --- | --- | --- | --- | --- | --- | --- | --- |
| 1 | 1 | **后台开发计划** | 26d | 2017-11-01 08:00 | 2017-12-06 17:00 |  | -3.25d | 0d |  |  | 376h |
| 2 | 1.1 | 后台开发框架的搭建 | 2d | 2017-11-01 08:00 | 2017-11-02 17:00 |  | -3.25d | 0d | start no earlier than 2017-11-01 08:00 | 田军 | 16h |
| 3 | 1.2 | **核心功能组件开发** | 24d | 2017-11-03 08:00 | 2017-12-06 17:00 |  | -3.25d | 0d |  | 田军 | 192h |
| 4 | 1.2.1 | **数据校验** | 16d | 2017-11-03 08:00 | 2017-11-24 17:00 |  | -3.25d | 0d |  |  |  |
| 5 | 1.2.1.1 | **考务数据校验** | 8d | 2017-11-03 08:00 | 2017-11-14 17:00 |  | -3.25d | 0d |  |  |  |
| 6 | 1.2.1.1.1 | 通用机考 | 7d | 2017-11-03 08:00 | 2017-11-13 17:00 | 2 | -3.25d | 0d |  |  |  |
| 7 | 1.2.1.1.2 | 优特机考 | 1d | 2017-11-14 08:00 | 2017-11-14 17:00 | 6 | -3.25d | 0d |  |  |  |
| 8 | 1.2.1.2 | **考试结果数据校验** | 8d | 2017-11-15 08:00 | 2017-11-24 17:00 |  | -3.25d | 0d |  |  |  |
| 9 | 1.2.1.2.1 | 通用机考 | 7d | 2017-11-15 08:00 | 2017-11-23 17:00 | 7 | -3.25d | 0d |  |  |  |
| 10 | 1.2.1.2.2 | 优特机考 | 1d | 2017-11-24 08:00 | 2017-11-24 17:00 | 9 | -3.25d | 0d |  |  |  |
| 11 | 1.2.2 | **数据存储** | 6d | 2017-11-27 08:00 | 2017-12-04 17:00 |  | -3.25d | 0d |  |  |  |
| 12 | 1.2.2.1 | **考务数据存储** | 3d | 2017-11-27 08:00 | 2017-11-29 17:00 |  | -3.25d | 0d |  |  |  |
| 13 | 1.2.2.1.1 | 文件存储 | 1d | 2017-11-27 08:00 | 2017-11-27 17:00 | 10 | -3.25d | 0d |  |  |  |
| 14 | 1.2.2.1.2 | 数据存储 | 2d | 2017-11-28 08:00 | 2017-11-29 17:00 | 13 | -3.25d | 0d |  |  |  |
| 15 | 1.2.2.2 | **考试结果数据存储** | 3d | 2017-11-30 08:00 | 2017-12-04 17:00 |  | -3.25d | 0d |  |  |  |
| 16 | 1.2.2.2.1 | 文件存储 | 1d | 2017-11-30 08:00 | 2017-11-30 17:00 | 14 | -3.25d | 0d |  |  |  |
| 17 | 1.2.2.2.2 | 数据存储 | 2d | 2017-12-01 08:00 | 2017-12-04 17:00 | 16 | -3.25d | 0d |  |  |  |
| 18 | 1.2.3 | **阅卷数据导出组件** | 1.5d | 2017-12-05 08:00 | 2017-12-06 12:00 |  | -3.25d | 0d |  |  |  |
| 19 | 1.2.3.1 | 通用机考 | 6h | 2017-12-05 08:00 | 2017-12-05 15:00 | 17 | -3.25d | 0d |  |  |  |
| 20 | 1.2.3.2 | 新光机考 | 6h | 2017-12-05 15:00 | 2017-12-06 12:00 | 19 | -3.25d | 0d |  |  |  |
| 21 | 1.2.4 | 通用文件上传组件 | 4h | 2017-12-06 13:00 | 2017-12-06 17:00 | 20 | -3.25d | 0d |  |  |  |
| 22 | 1.3 | **接口开发** | 21d | 2017-11-03 08:00 | 2017-12-01 17:00 |  | 0d |  |  | 高兴 | 168h |
| 23 | 1.3.1 | **考试任务管理** | 2.75d | 2017-11-07 10:00 | 2017-11-09 17:00 |  | 10.38d |  |  |  |  |
| 24 | 1.3.1.1 | 列表 | 2h | 2017-11-07 10:00 | 2017-11-07 12:00 | 44 | 10.38d | 0d |  |  |  |
| 25 | 1.3.1.2 | 新增考试任务 | 4h | 2017-11-07 13:00 | 2017-11-07 17:00 | 24 | 10.38d | 0d |  |  |  |
| 26 | 1.3.1.3 | 编辑考试任务 | 4h | 2017-11-08 08:00 | 2017-11-08 12:00 | 25 | 10.38d | 0d |  |  |  |
| 27 | 1.3.1.4 | 发布考试任务 | 4h | 2017-11-08 13:00 | 2017-11-08 17:00 | 26 | 10.38d | 0d |  |  |  |
| 28 | 1.3.1.5 | 查看考场数据 | 4h | 2017-11-09 08:00 | 2017-11-09 12:00 | 27 | 10.38d | 0d |  |  |  |
| 29 | 1.3.1.6 | 查看考务数据 | 4h | 2017-11-09 13:00 | 2017-11-09 17:00 | 28 | 10.38d | 10d |  |  |  |

| ID | WBS | Task | Duration | Start | Finish | Predecessors | Total slack | Free slack | Constraint | Resources | Work |
| --- | --- | --- | --- | --- | --- | --- | --- | --- | --- | --- | --- |
| 30 | 1.3.2 | **结果汇总数据** | 6d | 2017-11-24 08:00 | 2017-12-01 17:00 |  |  |  |  |  |  |
| 31 | 1.3.2.1 | 汇总进度列表 | 4h | 2017-11-24 08:00 | 2017-11-24 12:00 | 29 | 0.38d | 0d |  |  |  |
| 32 | 1.3.2.2 | 批量本地导入接口 | 4h | 2017-11-24 13:00 | 2017-11-24 17:00 | 31 | 0.38d | 0d |  |  |  |
| 33 | 1.3.2.3 | 导出阅卷数据 | 8h | 2017-11-27 08:00 | 2017-11-27 17:00 | 32 | 0.38d | 0d |  |  |  |
| 34 | 1.3.2.4 | **查询统计** | 3.62d | 2017-11-28 08:00 | 2017-12-01 14:00 |  | 0.38d |  |  |  |  |
| 35 | 1.3.2.4.1 | 列表接口 | 5h | 2017-11-28 08:00 | 2017-11-28 14:00 | 33 | 0.38d | 0d |  |  |  |
| 36 | 1.3.2.4.2 | 导出统计报表接口 | 3d | 2017-11-28 14:00 | 2017-12-01 14:00 | 35 | 0.38d |  |  |  |  |
| 37 | 1.3.3 | **系统管理** | 2.25d | 2017-11-03 08:00 | 2017-11-07 10:00 |  | 10.38d |  |  |  |  |
| 38 | 1.3.3.1 | **用户管理** | 1.5d | 2017-11-03 08:00 | 2017-11-06 12:00 |  | 10.38d |  |  |  |  |
| 39 | 1.3.3.1.1 | 添加用户 | 4h | 2017-11-03 08:00 | 2017-11-03 12:00 | 2 | 10.38d | 0d |  |  |  |
| 40 | 1.3.3.1.2 | 修改用户 | 4h | 2017-11-03 13:00 | 2017-11-03 17:00 | 39 | 10.38d | 0d |  |  |  |
| 41 | 1.3.3.1.3 | 删除用户 | 4h | 2017-11-06 08:00 | 2017-11-06 12:00 | 40 | 10.38d | 0d |  |  |  |
| 42 | 1.3.3.2 | 登录 | 2h | 2017-11-06 13:00 | 2017-11-06 15:00 | 41 | 10.38d | 0d |  |  |  |
| 43 | 1.3.3.3 | 登出 | 2h | 2017-11-06 15:00 | 2017-11-06 17:00 | 42 | 10.38d | 0d |  |  |  |
| 44 | 1.3.3.4 | 修改密码 | 2h | 2017-11-07 08:00 | 2017-11-07 10:00 | 43 | 10.38d | 0d |  |  |  |
| 46 | 2 | **前端开发计划** | 7d | 2017-12-07 08:00 | 2017-12-15 17:00 |  | -3.25d | 0d |  | 田军 | 56h |
| 47 | 2.1 | 前端开发框架搭建 | 2d | 2017-12-07 08:00 | 2017-12-08 17:00 | 21 | -3.25d | 0d | start no earlier than 2017-12-07 08:00 |  |  |
| 48 | 2.2 | **考试任务管理** | 1d | 2017-12-07 08:00 | 2017-12-07 17:00 |  |  |  |  |  |  |
| 49 | 2.2.1 | 列表页面 | 2h | 2017-12-11 08:00 | 2017-12-11 10:00 | 47 | -3.25d | 0d |  |  |  |
| 50 | 2.2.2 | 添加考试任务 | 6h | 2017-12-11 10:00 | 2017-12-11 17:00 | 49 | -3.25d | 0d |  |  |  |
| 51 | 2.2.3 | 修改考试任务 | 2h | 2017-12-12 08:00 | 2017-12-12 10:00 | 50 | -3.25d | 0d |  |  |  |
| 52 | 2.2.4 | 删除考试任务 | 2h | 2017-12-12 10:00 | 2017-12-12 12:00 | 51 | -3.25d | 0d |  |  |  |
| 53 | 2.2.5 | 查看考场数据 | 2h | 2017-12-12 13:00 | 2017-12-12 15:00 | 52 | -3.25d | 0d |  |  |  |
| 54 | 2.2.6 | 查看考务数据 | 4h | 2017-12-12 15:00 | 2017-12-13 10:00 | 53 | -3.25d | 0d |  |  |  |

| ID | WBS | Task | Duration | Start | Finish | Predecessors | Total slack |
| --- | --- | --- | --- | --- | --- | --- | --- |
| 55 | 2.3 | **结果汇总进度** | 0.5d | 2017-12-13 10:00 | 2017-12-13 15:00 |  | 0d |
| 56 | 2.3.1 | 列表页面 | 2h | 2017-12-13 10:00 | 2017-12-13 12:00 | 54 | 0d |
| 57 | 2.3.2 | 导入导出 | 2h | 2017-12-13 13:00 | 2017-12-13 15:00 | 56 | 0d |
| 58 | 2.4 | **查询统计** | 0.25d | 2017-12-13 15:00 | 2017-12-13 17:00 |  | 0d |
| 59 | 2.4.1 | 列表页面 | 2h | 2017-12-13 15:00 | 2017-12-13 17:00 | 57 | 0d |
| 60 | 2.5 | **系统管理** | 2d | 2017-12-14 08:00 | 2017-12-15 17:00 |  | 0d |
| 61 | 2.5.1 | 登录页面 | 4h | 2017-12-14 08:00 | 2017-12-14 12:00 | 59 | 0d |
| 62 | 2.5.2 | **用户管理** | 1d | 2017-12-14 13:00 | 2017-12-15 12:00 |  | 0d |
| 63 | 2.5.2.1 | 添加用户 | 3h | 2017-12-14 13:00 | 2017-12-14 16:00 | 61 | 0d |
| 64 | 2.5.2.2 | 修改用户 | 3h | 2017-12-14 16:00 | 2017-12-15 10:00 | 63 | 0d |
| 65 | 2.5.2.3 | 删除用户 | 2h | 2017-12-15 10:00 | 2017-12-15 12:00 | 64 | 0d |
| 66 | 2.5.3 | 用户修改密码 | 4h | 2017-12-15 13:00 | 2017-12-15 17:00 | 65 | 0d |
